# داش ابی 84-10-13

Schedule from MS Project, 2007-02-03 to 2007-08-13, costs in $.
INDUSTRIAL ENGINEERING

## Calendars

- Standard: Mon-Sun 08:00-12:00, 13:00-17:00.

## Resources

| Resource | Unit | Rate | Cost per use |
| --- | --- | --- | --- |
| کارگر ساده |  | 1 |  |
| لودر |  | 8 | 20 |
| کامیون |  | 3 | 20 |
| ماسه | متر مکعب | 10 | 1 |
| سیمان | کیسه | 4 | 0.2 |
| میلگرد | شاخه | 2 | 0.01 |
| آرماتور بند |  | 3 | 3 |
| فرغون |  |  |  |
| مقنی |  | 3 | 1 |
| سفال سقفی | کامیون |  | 10 |
| سفال دیوار | کامیون |  | 10 |
| بنا (معمار) |  | 4 | 1 |
| نصاب در و پنجره |  | 3 | 4 |
| لوله پولیکا | شاخه | 2 | 0.01 |
| لوله سبز | شاخه | 1 | 0.01 |
| لوله کش |  | 3 | 2 |
| گونی | متر مربع | 0.2 | 0.01 |
| قیر | بشکه | 12 | 0.02 |
| آسفالت کار |  | 2 | 5 |
| بتونیر |  |  |  |
| ویبراتور |  |  |  |
| قالب |  |  |  |
| لوله آب | شاخه | 6 | 0.01 |
| سیم برق | متر | 0.4 |  |
| سیم تلفن | متر | 0.1 |  |
| سیم آرماتور | متر | 0.05 |  |
| برق کار |  | 5 | 1 |
| ورق کانال هوا | متر مربع | 4 | 0.05 |
| کانال کش |  | 3 | 1 |
| سنگ نما | متر مربع | 7 | 0.2 |
| سنگ کار |  | 3 | 1 |
| سرامیک | متر مربع | 6 | 0.1 |
| شیرآلات وتجهیزات بهداشتی | بسته | 300 | 2 |
| خاک رس | متر مکعب | 15 | 2 |
| توری راویز | متر مربع | 1 | 0.2 |
| راویز کار |  | 4 | 3 |
| گچ | کیسه | 2 | 0.2 |
| گچکار |  | 4 | 3 |
| کابینت | متر مکعب | 8 | 1 |
| کلید وپریز | عدد | 5 |  |
| موکت | متر مربع | 3 | 0.15 |
| جوشکار |  | 2 | 1 |
| نصاب کابینت |  | 2 | 0.8 |
| لوله گاز | متر | 8 | 0.03 |
| لوله کش گاز |  | 4 | 2 |
| تجهیزات آردواز | متر مربع | 4.5 | 0.06 |
| نصاب آردواز |  | 3 | 0.5 |

## Schedule

| ID | WBS | Task | Duration | Start | Finish | Predecessors | Baseline start | Baseline finish | Baseline duration | Total slack | Free slack | Resources | Work | Cost | Baseline cost |
| --- | --- | --- | --- | --- | --- | --- | --- | --- | --- | --- | --- | --- | --- | --- | --- |
| 1 | 1 | **مجتمع مسکونی گل یخ** | 192d | 2007-02-03 | 2007-08-13 |  | 2007-02-03 | 2007-08-13 | 192d | 0d |  |  | 611.09h | 167,165.74 | 167,165.74 |
| 2 | 1.1 | **امور مربوط به شهرداری ومهندسین ساختمان** | 50d | 2007-02-03 | 2007-03-24 |  | 2007-02-03 | 2007-03-24 | 50d | 0d |  |  |  |  |  |
| 3 | 1.1.1 | طی مراحل قانونی | 30d | 2007-02-03 | 2007-03-04 |  | 2007-02-03 | 2007-03-04 | 30d | 0d |  |  |  |  |  |
| 4 | 1.1.2 | اخذ مجوز ساخت | 20d | 2007-03-05 | 2007-03-24 | 3 | 2007-03-05 | 2007-03-24 | 20d | 0d |  |  |  |  |  |
| 5 | 1.1.3 | مشاوره واستخدام مهندسین ساختمان | 10d | 2007-02-03 | 2007-02-12 |  | 2007-02-03 | 2007-02-12 | 10d | 157d | 0d |  |  |  |  |
| 6 | 1.1.4 | (oyout ) فنی ساختمان نقشه های | 9d | 2007-02-13 | 2007-02-21 | 5 | 2007-02-13 | 2007-02-21 | 9d | 157d |  |  |  |  |  |
| 7 | 1.1.5 | معرفی مهندس ناظر -پیمانکار -عوامل اجرایی رده بالاوتکمیل قرار دادها | 7d | 2007-02-03 | 2007-02-09 |  | 2007-02-03 | 2007-02-09 | 7d | 46d |  |  |  |  |  |
| 8 | 1.2 | **اجرای فاز اول پروزه** | 16d | 2007-03-25 | 2007-04-09 |  | 2007-03-25 | 2007-04-09 | 16d | 0d |  |  | 0.64h | 503.52 | 503.52 |
| 9 | 1.2.1 | **مصالح ساختمانی وتجهیزات** | 16d | 2007-03-25 | 2007-04-09 |  | 2007-03-25 | 2007-04-09 | 16d | 126d |  |  |  | 500 | 500 |
| 10 | 1.2.1.1 | سفارش ودریافت سیمان ومیلگردوماسه مصالح ساختمانی | 14d | 2007-03-25 | 2007-04-07 | 2 | 2007-03-25 | 2007-04-07 | 14d | 126d | 0d |  |  |  |  |
| 11 | 1.2.1.2 | انبارش مصالح ساختمانی | 2d | 2007-04-08 | 2007-04-09 | 10 | 2007-04-08 | 2007-04-09 | 2d | 126d |  |  |  |  |  |
| 12 | 1.2.1.3 | خریداری ماشین آلات و تجهیزات | 7d | 2007-03-25 | 2007-03-31 | 2 | 2007-03-25 | 2007-03-31 | 7d | 135d |  |  |  | 500 | 500 |
| 13 | 1.2.2 | **عملیات خاک برداری** | 5d | 2007-03-25 | 2007-03-29 |  | 2007-03-25 | 2007-03-29 | 5d | 0d |  |  | 0.64h | 3.52 | 3.52 |
| 14 | 1.2.2.1 | هماهنگی با مخابرات وسازمان آب وگازوتلفن | 3d | 2007-03-25 | 2007-03-27 | 4 | 2007-03-25 | 2007-03-27 | 3d | 0d |  |  |  |  |  |
| 15 | 1.2.2.2 | خاک برداری | 2d | 2007-03-28 | 2007-03-29 | 14, 7 | 2007-03-28 | 2007-03-29 | 2d | 0d |  | کامیون [3%]; لودر [1%] | 0.64h | 3.52 | 3.52 |
| 16 | 1.3 | **اجرای فاز دوم پروزه** | 86d | 2007-03-30 | 2007-06-23 |  | 2007-03-30 | 2007-06-23 | 86d | 0d |  |  | 428.37h | 8,125.21 | 8,125.21 |
| 17 | 1.3.1 | **اجرای فنداسیون** | 11d | 2007-03-30 | 2007-04-09 |  | 2007-03-30 | 2007-04-09 | 11d | 0d |  |  | 32.64h | 750.68 | 750.68 |
| 18 | 1.3.1.1 | ریختن ملات در کف زمین | 2d | 2007-03-30 | 2007-03-31 | 15 | 2007-03-30 | 2007-03-31 | 2d | 0d |  | بنا (معمار) [1%]; سیمان [10 کیسه]; فرغون [4%]; کارگر ساده [4%] | 1.44h | 41.49 | 41.49 |
| 19 | 1.3.1.2 | شبکه بندی کف با میلگرد | 7d | 2007-04-01 | 2007-04-07 | 18 | 2007-04-01 | 2007-04-07 | 7d | 0d |  | آرماتور بند [4%]; سیم آرماتور [500 متر]; میلگرد [300 شاخه]; قالب [50%] | 30.24h | 631.85 | 631.85 |
| 20 | 1.3.1.3 | بتن ریزی | 1d | 2007-04-08 | 2007-04-08 | 19 | 2007-04-08 | 2007-04-08 | 1d | 0d |  | کارگر ساده [8%] | 0.64h | 0.64 | 0.64 |
| 21 | 1.3.1.4 | قیر گونی پی ساختمان (پی ساختمان عایق بندی شده) | 1d | 2007-04-09 | 2007-04-09 | 20 | 2007-04-09 | 2007-04-09 | 1d | 122d | 0d | آسفالت کار [2.7%]; قیر [3 بشکه]; کارگر ساده [1.3%]; گونی [200 متر مربع] | 0.32h | 76.7 | 76.7 |
| 22 | 1.3.2 | **سفت کاری** | 76d | 2007-04-09 | 2007-06-23 |  | 2007-04-09 | 2007-06-23 | 76d | 0d |  |  | 395.73h | 7,374.53 | 7,374.53 |
| 23 | 1.3.2.1 | **سفت کاری طبقه اول** | 19d | 2007-04-09 | 2007-04-27 |  | 2007-04-09 | 2007-04-27 | 19d | 0d |  |  | 241.37h | 1,254.88 | 1,254.88 |
| 24 | 1.3.2.1.1 | شبکه بندی با میلگرد(ستونهای طبقه اول) | 5d | 2007-04-09 | 2007-04-13 | 20 | 2007-04-09 | 2007-04-13 | 5d | 0d |  | آرماتور بند [4%]; سیم آرماتور [500 متر]; قالب [200%]; میلگرد [100 شاخه] | 81.6h | 229.93 | 229.93 |
| 25 | 1.3.2.1.2 | بتن ریزی ستون های طبقه اول | 1d | 2007-04-14 | 2007-04-14 | 24 | 2007-04-14 | 2007-04-14 | 1d | 0d |  | بتونیر [0.1%]; فرغون [0.3%]; سیمان [20 کیسه]; ماسه [10 متر مکعب]; ویبراتور [0.1%]; آرماتور بند [0.4%]; کارگر ساده [4%] | 0.4h | 181.64 | 181.64 |
| 26 | 1.3.2.1.3 | شبکه بندی با میلگرد سقف طبقه اول | 8d | 2007-04-15 | 2007-04-22 | 25 | 2007-04-15 | 2007-04-22 | 8d | 0d |  | میلگرد [200 شاخه]; آرماتور بند [4%]; قالب [200%]; سیم آرماتور [500 متر]; کارگر ساده [2%]; سفال سقفی [1 کامیون] | 131.84h | 444.09 | 444.09 |
| 27 | 1.3.2.1.4 | بتن ریزی سقف طبقه اول | 1d | 2007-04-23 | 2007-04-23 | 26 | 2007-04-23 | 2007-04-23 | 1d | 0d |  | بتونیر [1%]; سیمان [50 کیسه]; فرغون [4%]; کارگر ساده [5%]; ویبراتور [1%] | 0.88h | 200.6 | 200.6 |
| 28 | 1.3.2.1.5 | شبکه بندی راه پله بین طبقه اول و دوم | 3d | 2007-04-24 | 2007-04-26 | 27 | 2007-04-24 | 2007-04-26 | 3d | 0d |  | آرماتور بند [4.1%]; سیم آرماتور [300 متر]; قالب [102.9%]; میلگرد [50 شاخه]; بتونیر [1%] | 25.92h | 118.09 | 118.09 |
| 29 | 1.3.2.1.6 | بتن ریزی راه پله بین طبقه اول و دوم | 1d | 2007-04-27 | 2007-04-27 | 28 | 2007-04-27 | 2007-04-27 | 1d | 0d |  | بتونیر [0.8%]; سیمان [20 کیسه]; فرغون [3.3%]; ویبراتور [0.8%]; کارگر ساده [4.2%] | 0.73h | 80.53 | 80.53 |

| ID | WBS | Task | Duration | Start | Finish | Predecessors | Baseline start | Baseline finish | Baseline duration | Total slack | Free slack | Resources | Work | Cost | Baseline cost |
| --- | --- | --- | --- | --- | --- | --- | --- | --- | --- | --- | --- | --- | --- | --- | --- |
| 30 | 1.3.2.2 | **سفت کاری طبقه دوم** | 19d | 2007-04-28 | 2007-05-16 |  | 2007-04-28 | 2007-05-16 | 19d | 0d |  |  | 46.43h | 1,593.75 | 1,593.75 |
| 31 | 1.3.2.2.1 | شبکه بندی با میلگرد(ستونهای طبقه دوم) | 5d | 2007-04-28 | 2007-05-02 | 29 | 2007-04-28 | 2007-05-02 | 5d | 0d |  | آرماتور بند [4%]; سیم آرماتور [300 متر]; قالب; میلگرد [200 شاخه] | 41.6h | 419.93 | 419.93 |
| 32 | 1.3.2.2.2 | بتن ریزی ستون های طبقه دوم | 1d | 2007-05-03 | 2007-05-03 | 31 | 2007-05-03 | 2007-05-03 | 1d | 0d |  | بتونیر [0.9%]; سیمان [50 کیسه]; فرغون [4.3%]; ویبراتور [0.9%]; آرماتور بند [3.4%] | 0.75h | 201.13 | 201.13 |
| 33 | 1.3.2.2.3 | شبکه بندی با میلگرد سقف طبقه دوم | 8d | 2007-05-04 | 2007-05-11 | 32 | 2007-05-04 | 2007-05-11 | 8d | 0d |  | آرماتور بند [0.1%]; سیم آرماتور [300 متر]; قالب [3.9%]; میلگرد [100 شاخه]; سفال سقفی [1 کامیون] | 2.56h | 225.16 | 225.16 |
| 34 | 1.3.2.2.4 | بتن ریزی سقف طبقه دوم | 1d | 2007-05-12 | 2007-05-12 | 33 | 2007-05-12 | 2007-05-12 | 1d | 0d |  | بتونیر [0.1%]; سیمان [50 کیسه]; فرغون [0.4%]; کارگر ساده [0.5%]; ماسه [20 متر مکعب] | 0.08h | 401.24 | 401.24 |
| 35 | 1.3.2.2.5 | شبکه بندی راه پله بین طبقه سوم و دوم | 3d | 2007-05-13 | 2007-05-15 | 34 | 2007-05-13 | 2007-05-15 | 3d | 0d |  | آرماتور بند [0.1%]; سیم آرماتور [300 متر]; قالب [3.9%]; میلگرد [100 شاخه] | 0.96h | 215.09 | 215.09 |
| 36 | 1.3.2.2.6 | بتن ریزی راه پله بین طبقه سوم و دوم | 1d | 2007-05-16 | 2007-05-16 | 35 | 2007-05-16 | 2007-05-16 | 1d | 0d |  | بتونیر [1%]; سیمان [20 کیسه]; فرغون [4%]; ماسه [5 متر مکعب]; ویبراتور [1%] | 0.48h | 131.2 | 131.2 |
| 37 | 1.3.2.3 | **سفت کاری طبقه سوم** | 19d | 2007-05-17 | 2007-06-04 |  | 2007-05-17 | 2007-06-04 | 19d | 0d |  |  | 20.8h | 1,833.09 | 1,833.09 |
| 38 | 1.3.2.3.1 | شبکه بندی با میلگرد(ستونهای طبقه سوم) | 5d | 2007-05-17 | 2007-05-21 | 36 | 2007-05-17 | 2007-05-21 | 5d | 0d |  | آرماتور بند [4%]; سیم آرماتور [300 متر]; میلگرد [120 شاخه] | 1.6h | 259.93 | 259.93 |
| 39 | 1.3.2.3.2 | بتن ریزی ستون های طبقه سوم | 1d | 2007-05-22 | 2007-05-22 | 38 | 2007-05-22 | 2007-05-22 | 1d | 0d |  | بتونیر [1%]; سیمان [20 کیسه]; فرغون [4%]; کارگر ساده [4%]; ویبراتور [1%] | 0.8h | 80.52 | 80.52 |
| 40 | 1.3.2.3.3 | شبکه بندی با میلگرد سقف طبقه سوم | 8d | 2007-05-23 | 2007-05-30 | 39 | 2007-05-23 | 2007-05-30 | 8d | 0d |  | آرماتور بند [4%]; سفال سقفی [1 کامیون]; سیم آرماتور [500 متر]; کارگر ساده [2%]; میلگرد [400 شاخه] | 3.84h | 844.09 | 844.09 |
| 41 | 1.3.2.3.4 | بتن ریزی سقف طبقه سوم | 1d | 2007-05-31 | 2007-05-31 | 40 | 2007-05-31 | 2007-05-31 | 1d | 0d |  | بتونیر [1%]; سیمان [50 کیسه]; فرغون [4%]; کارگر ساده [4%]; ماسه [10 متر مکعب]; ویبراتور [1%] | 0.8h | 301.52 | 301.52 |
| 42 | 1.3.2.3.5 | شبکه بندی راه پله بین طبقه سوم وچهارم | 3d | 2007-06-01 | 2007-06-03 | 41 | 2007-06-01 | 2007-06-03 | 3d | 0d |  | آرماتور بند [4%]; سیم آرماتور [250 متر]; میلگرد [100 شاخه]; قالب [50%] | 12.96h | 215.51 | 215.51 |
| 43 | 1.3.2.3.6 | بتن ریزی راه پله بین طبقه سوم و چهارم | 1d | 2007-06-04 | 2007-06-04 | 42 | 2007-06-04 | 2007-06-04 | 1d | 0d |  | ویبراتور [1%]; بتونیر [1%]; سیمان [20 کیسه]; کارگر ساده [4%]; فرغون [4%]; ماسه [5 متر مکعب] | 0.8h | 131.52 | 131.52 |
| 44 | 1.3.2.4 | **سفت کاری طبقه چهارم** | 19d | 2007-06-05 | 2007-06-23 |  | 2007-06-05 | 2007-06-23 | 19d | 0d |  |  | 87.12h | 2,692.81 | 2,692.81 |
| 45 | 1.3.2.4.1 | شبکه بندی با میلگرد(ستونهای طبقه چهارم) | 5d | 2007-06-05 | 2007-06-09 | 43 | 2007-06-05 | 2007-06-09 | 5d | 0d |  | آرماتور بند [4%]; سیم آرماتور [450 متر]; قالب [50%]; میلگرد [150 شاخه] | 21.6h | 327.43 | 327.43 |
| 46 | 1.3.2.4.2 | بتن ریزی ستون های طبقه چهارم | 1d | 2007-06-10 | 2007-06-10 | 45 | 2007-06-10 | 2007-06-10 | 1d | 0d |  | بتونیر [1%]; سیمان [50 کیسه]; کارگر ساده [4%]; ماسه [20 متر مکعب]; فرغون [4%]; ویبراتور [1%] | 0.8h | 401.52 | 401.52 |
| 47 | 1.3.2.4.3 | شبکه بندی با میلگرد سقف طبقه چهارم | 8d | 2007-06-11 | 2007-06-18 | 46 | 2007-06-11 | 2007-06-18 | 8d | 0d |  | آرماتور بند [4%]; سفال سقفی [2 کامیون]; سیم آرماتور [500 متر]; قالب [80%]; میلگرد [400 شاخه] | 53.76h | 842.81 | 842.81 |
| 48 | 1.3.2.4.4 | بتن ریزی سقف طبقه چهارم | 1d | 2007-06-19 | 2007-06-19 | 47 | 2007-06-19 | 2007-06-19 | 1d | 0d |  | بتونیر [1%]; ویبراتور [1%]; سیمان [80 کیسه]; فرغون [4%]; کارگر ساده [4%]; ماسه [50 متر مکعب] | 0.8h | 821.52 | 821.52 |
| 49 | 1.3.2.4.5 | شبکه بندی راه پله بین طبقه پنجم وچهارم | 3d | 2007-06-20 | 2007-06-22 | 48 | 2007-06-20 | 2007-06-22 | 3d | 0d |  | آرماتور بند [4%]; سیم آرماتور [300 متر]; قالب [35%]; میلگرد [50 شاخه] | 9.36h | 118.01 | 118.01 |
| 50 | 1.3.2.4.6 | بتن ریزی راه پله بین طبقه پنجم و چهارم | 1d | 2007-06-23 | 2007-06-23 | 49 | 2007-06-23 | 2007-06-23 | 1d | 0d |  | ویبراتور [1%]; بتونیر [1%]; سیمان [20 کیسه]; فرغون [4%]; کارگر ساده [4%]; ماسه [10 متر مکعب] | 0.8h | 181.52 | 181.52 |
| 51 | 1.4 | **اجرای فاز سوم پروزه** | 126d | 2007-04-10 | 2007-08-13 |  | 2007-04-10 | 2007-08-13 | 126d | 0d |  |  | 170.72h | 158,277.24 | 158,277.24 |
| 52 | 1.4.1 | **نازک کاری** | 126d | 2007-04-10 | 2007-08-13 |  | 2007-04-10 | 2007-08-13 | 126d | 0d |  |  | 170.08h | 158,234.58 | 158,234.58 |
| 53 | 1.4.1.1 | چاه فاضلاب حفر شده به متراز از قبل تعیین شده | 4d | 2007-04-10 | 2007-04-13 | 21 | 2007-04-10 | 2007-04-13 | 4d | 122d |  | فرغون [4%]; مقنی [2%]; کارگر ساده [2%] | 2.56h | 2.58 | 2.58 |
| 54 | 1.4.1.2 | دیوار های طبقه اول بر اساس نقشه ساختمان | 7d | 2007-05-04 | 2007-05-10 | 29FS+2d | 2007-05-04 | 2007-05-10 | 7d | 76d | 0d | کارگر ساده [4%]; بنا (معمار) [1%]; سفال دیوار [3 کامیون]; سیمان [30 کیسه]; فرغون [4%]; ماسه [30 متر مکعب] | 5.04h | 435.69 | 435.69 |
| 55 | 1.4.1.3 | دیوار های طبقه دوم بر اساس نقشه ساختمان | 7d | 2007-05-23 | 2007-05-29 | 36FS+2d | 2007-05-23 | 2007-05-29 | 7d | 57d | 0d | بنا (معمار) [2%]; سفال دیوار [3 کامیون]; سیمان [30 کیسه]; فرغون [4%]; کارگر ساده [4%]; ماسه [40 متر مکعب] | 5.6h | 537.94 | 537.94 |
| 56 | 1.4.1.4 | دیوار های طبقه سوم بر اساس نقشه ساختمان | 8d | 2007-06-11 | 2007-06-18 | 43FS+2d | 2007-06-11 | 2007-06-18 | 8d | 30d | 0d | بنا (معمار) [2%]; سفال دیوار [3 کامیون]; سیمان [30 کیسه]; فرغون [4%]; کارگر ساده [4%]; ماسه [40 متر مکعب] | 6.4h | 538.9 | 538.9 |
| 57 | 1.4.1.5 | دیوار های طبقه چهارم بر اساس نقشه ساختمان | 9d | 2007-06-26 | 2007-07-04 | 50FS+2d | 2007-06-26 | 2007-07-04 | 9d | 0d |  | بنا (معمار) [2%]; سفال دیوار [3 کامیون]; سیمان [30 کیسه]; فرغون [4%]; کارگر ساده [5%]; ماسه [40 متر مکعب] | 7.92h | 540.58 | 540.58 |
| 58 | 1.4.1.6 | سفارش ودریافت و ساخت درب وپنجره وچهار چوب | 12d | 2007-07-05 | 2007-07-16 | 57 | 2007-07-05 | 2007-07-16 | 12d | 19d | 0d |  |  |  |  |
| 59 | 1.4.1.7 | نصب چهار چوبهاودربها وپنجرههاوعایق بندی فضاها | 9d | 2007-07-17 | 2007-07-25 | 58 | 2007-07-17 | 2007-07-25 | 9d | 19d |  | کارگر ساده [2%]; نصاب در و پنجره [2%] | 2.88h | 5.84 | 5.84 |
| 60 | 1.4.1.8 | لوله های آب و فاضلاب نصب شده | 6d | 2007-07-05 | 2007-07-10 | 57 | 2007-07-05 | 2007-07-10 | 6d | 34d |  | لوله کش [2%]; کارگر ساده [1%]; لوله آب [10 شاخه]; لوله پولیکا [50 شاخه]; لوله سبز [50 شاخه] | 1.44h | 213.43 | 213.43 |
| 61 | 1.4.1.9 | لوله نصب شده تاسیسات حرارتی وبرودتی | 8d | 2007-07-05 | 2007-07-12 | 57 | 2007-07-05 | 2007-07-12 | 8d | 32d |  | لوله کش [2%]; کارگر ساده [3%]; لوله آب [80 شاخه] | 3.2h | 485.81 | 485.81 |
| 62 | 1.4.1.10 | سیم کشی برق وتلفن ساختمان | 5d | 2007-07-05 | 2007-07-09 | 57 | 2007-07-05 | 2007-07-09 | 5d | 35d |  | کارگر ساده [1%]; سیم برق [1000 متر]; سیم تلفن [400 متر]; برق کار [1%] | 0.8h | 442.41 | 442.41 |
| 63 | 1.4.1.11 | کانالهای نصب شده برای تهویه هوا | 9d | 2007-07-05 | 2007-07-13 | 57 | 2007-07-05 | 2007-07-13 | 9d | 31d |  | کارگر ساده [4%]; کانال کش [2%]; ورق کانال هوا [250 متر مربع] | 4.32h | 1,007.27 | 1,007.27 |
| 64 | 1.4.1.12 | سنگ کردن نمای ساختمان | 40d | 2007-07-05 | 2007-08-13 | 57 | 2007-07-05 | 2007-08-13 | 40d | 0d |  | سنگ نما [700 متر مربع]; سنگ کار [4%]; کارگر ساده [4%]; سیمان [50 کیسه]; ماسه [50 متر مکعب] | 25.6h | 5,652.64 | 5,652.64 |
| 65 | 1.4.1.13 | قیر کونی بام وآسفالت آن | 2d | 2007-06-20 | 2007-06-21 | 48 | 2007-06-20 | 2007-06-21 | 2d | 53d |  | آسفالت کار [4%]; کارگر ساده [2%]; گونی [500 متر مربع]; قیر [5 بشکه] | 0.96h | 161.83 | 161.83 |
| 66 | 1.4.1.14 | موزاییک یاسرامیک کردن ودوغاب کردن طبقه اول | 4d | 2007-05-11 | 2007-05-14 | 54 | 2007-05-11 | 2007-05-14 | 4d | 91d |  | بنا (معمار) [1%]; سرامیک [200 متر مربع]; سیمان [30 کیسه]; کارگر ساده [5%]; ماسه [20 متر مکعب] | 1.92h | 1,524.19 | 1,524.19 |
| 67 | 1.4.1.15 | موزاییک یاسرامیک کردن ودوغاب کردن طبقه دوم | 4d | 2007-05-30 | 2007-06-02 | 55 | 2007-05-30 | 2007-06-02 | 4d | 72d |  | بنا (معمار) [1%]; سرامیک [200 متر مربع]; سیمان [30 کیسه]; کارگر ساده [5%]; ماسه [20 متر مکعب] | 1.92h | 1,524.19 | 1,524.19 |
| 68 | 1.4.1.16 | موزاییک یاسرامیک کردن ودوغاب کردن طبقه سوم | 5d | 2007-06-19 | 2007-06-23 | 56 | 2007-06-19 | 2007-06-23 | 5d | 51d |  | بنا (معمار) [1%]; سرامیک [200 متر مربع]; سیمان [30 کیسه]; کارگر ساده [5%]; ماسه [20 متر مکعب] | 2.4h | 1,524.91 | 1,524.91 |
| 69 | 1.4.1.17 | موزاییک یاسرامیک کردن ودوغاب کردن طبقه چهارم | 5d | 2007-07-05 | 2007-07-09 | 57 | 2007-07-05 | 2007-07-09 | 5d | 30d | 0d | بنا (معمار) [1%]; سرامیک [200 متر مربع]; سیمان [30 کیسه]; کارگر ساده [5%]; ماسه [20 متر مکعب] | 2.4h | 1,524.91 | 1,524.91 |
| 70 | 1.4.1.18 | سفارش و دریافت ونصب تجهیزات حرارتی وبرودتی در مکان پیش بینی شده | 6d | 2007-07-05 | 2007-07-10 | 57 | 2007-07-05 | 2007-07-10 | 6d | 34d |  | جوشکار [1%]; کارگر ساده [2%]; لوله کش [2%] | 2.4h | 4.85 | 4.85 |
| 71 | 1.4.1.19 | نصب شیرآ لات وتجهیزات بهداشتی | 5d | 2007-07-10 | 2007-07-14 | 69 | 2007-07-10 | 2007-07-14 | 5d | 30d |  | شیرآلات وتجهیزات بهداشتی [400 بسته]; کارگر ساده [2%]; بنا (معمار) [1%]; لوله کش [1%] | 1.6h | 120,005.63 | 120,005.63 |
| 72 | 1.4.1.20 | اجرای خاک گچ طبقه 1 | 5d | 2007-05-11 | 2007-05-15 | 54 | 2007-05-11 | 2007-05-15 | 5d | 90d |  | خاک رس [5 متر مکعب]; فرغون [2%]; کارگر ساده [2%]; گچ [100 کیسه]; گچکار [3%]; ماسه [1 متر مکعب] | 2.8h | 293.89 | 293.89 |
| 73 | 1.4.1.21 | اجرای خاک گچ طبقه 2 | 5d | 2007-06-05 | 2007-06-09 | 55 | 2007-06-05 | 2007-06-09 | 5d | 65d |  | خاک رس [5 متر مکعب]; فرغون [2%]; کارگر ساده [2%]; گچ [100 کیسه]; گچکار [3%]; ماسه [1 متر مکعب] | 2.8h | 293.89 | 293.89 |
| 74 | 1.4.1.22 | اجرای خاک گچ طبقه3 | 6d | 2007-07-09 | 2007-07-14 | 56 | 2007-07-09 | 2007-07-14 | 6d | 30d |  | خاک رس [5 متر مکعب]; فرغون [2%]; کارگر ساده [2%]; گچ [100 کیسه]; گچکار [3%]; ماسه [1 متر مکعب] | 3.36h | 295.01 | 295.01 |
| 75 | 1.4.1.23 | اجرای خاک گچ طبقه4 | 6d | 2007-07-15 | 2007-07-20 | 57 | 2007-07-15 | 2007-07-20 | 6d | 24d |  | خاک رس [5 متر مکعب]; فرغون [2%]; کارگر ساده [2%]; گچ [100 کیسه]; گچکار [30%]; ماسه [1 متر مکعب] | 16.32h | 347.66 | 347.66 |
| 76 | 1.4.1.24 | اجرای خاک گچ راه پله ها | 4d | 2007-07-05 | 2007-07-08 | 57 | 2007-07-05 | 2007-07-08 | 4d | 28d | 0d | خاک رس [8 متر مکعب]; فرغون [2%]; کارگر ساده [4%]; گچ [150 کیسه]; گچکار [3%] | 2.88h | 427.41 | 427.41 |
| 77 | 1.4.1.25 | اجرای راویزبرای طبقه اول | 6d | 2007-05-11 | 2007-05-16 | 54 | 2007-05-11 | 2007-05-16 | 6d | 76d | 0d | میلگرد [10 شاخه]; راویز کار [3%]; توری راویز [50 متر مربع]; کارگر ساده [2%]; گچ [30 کیسه]; گچکار [1%] | 2.88h | 139.17 | 139.17 |
| 78 | 1.4.1.26 | اجرای راویزبرای طبقه دوم | 6d | 2007-05-30 | 2007-06-04 | 55 | 2007-05-30 | 2007-06-04 | 6d | 57d | 0d | توری راویز [50 متر مربع]; راویز کار [3%]; کارگر ساده [2%]; گچ [30 کیسه]; گچکار [1%]; میلگرد [10 شاخه] | 2.88h | 139.17 | 139.17 |
| 79 | 1.4.1.27 | اجرای راویزبرای طبقه سوم | 6d | 2007-06-19 | 2007-06-24 | 56 | 2007-06-19 | 2007-06-24 | 6d | 37d | 0d | توری راویز [50 متر مربع]; راویز کار [3%]; کارگر ساده [2%]; گچ [30 کیسه]; گچکار [1%]; میلگرد [10 شاخه] | 2.88h | 139.17 | 139.17 |
| 80 | 1.4.1.28 | اجرای راویزبرای طبقه چهارم | 6d | 2007-07-05 | 2007-07-10 | 57 | 2007-07-05 | 2007-07-10 | 6d | 16d | 0d | توری راویز [50 متر مربع]; راویز کار [3%]; کارگر ساده [2%]; گچ [30 کیسه]; گچکار [1%]; میلگرد [10 شاخه] | 2.88h | 139.17 | 139.17 |
| 81 | 1.4.1.29 | اجرای گچکاری طبقه اول | 5d | 2007-05-17 | 2007-05-21 | 77 | 2007-05-17 | 2007-05-21 | 5d | 76d | 0d | کارگر ساده [2%]; گچ [100 کیسه]; گچکار [3%] | 2h | 205.89 | 205.89 |
| 82 | 1.4.1.30 | اجرای گچکاری طبقه دوم | 5d | 2007-06-05 | 2007-06-09 | 78 | 2007-06-05 | 2007-06-09 | 5d | 57d | 0d | کارگر ساده [2%]; گچ [100 کیسه]; گچکار [3%] | 2h | 205.89 | 205.89 |
| 83 | 1.4.1.31 | اجرای گچکاری طبقه سوم | 5d | 2007-06-25 | 2007-06-29 | 79 | 2007-06-25 | 2007-06-29 | 5d | 37d | 0d | کارگر ساده [2%]; گچ [100 کیسه]; گچکار [3%] | 2h | 205.89 | 205.89 |
| 84 | 1.4.1.32 | اجرای گچکاری طبقه چهارم | 5d | 2007-07-11 | 2007-07-15 | 80 | 2007-07-11 | 2007-07-15 | 5d | 16d | 0d | کارگر ساده [2%]; گچ [100 کیسه]; گچکار [3%] | 2h | 205.89 | 205.89 |
| 85 | 1.4.1.33 | اجرای گچکاری راه پله ها | 8d | 2007-07-09 | 2007-07-16 | 76 | 2007-07-09 | 2007-07-16 | 8d | 28d |  | کارگر ساده [4%]; گچ [250 کیسه]; گچکار [3%] | 4.48h | 510.53 | 510.53 |
| 86 | 1.4.1.34 | اجرای گچبری داخل طبقه1 | 3d | 2007-05-22 | 2007-05-24 | 81 | 2007-05-22 | 2007-05-24 | 3d | 76d | 0d | کارگر ساده [1%]; گچ [30 کیسه]; گچکار [1%] | 0.48h | 61.43 | 61.43 |
| 87 | 1.4.1.35 | اجرای گچبری داخل طبقه2 | 3d | 2007-06-10 | 2007-06-12 | 82 | 2007-06-10 | 2007-06-12 | 3d | 57d | 0d | کارگر ساده [2%]; گچ [30 کیسه]; گچکار [2%] | 0.96h | 62.66 | 62.66 |
| 88 | 1.4.1.36 | اجرای گچبری داخل طبقه3 | 3d | 2007-06-30 | 2007-07-02 | 83 | 2007-06-30 | 2007-07-02 | 3d | 37d | 0d | کارگر ساده [2%]; گچ [30 کیسه]; گچکار [2%] | 0.96h | 62.66 | 62.66 |
| 89 | 1.4.1.37 | اجرای گچبری داخل طبقه4 | 3d | 2007-07-16 | 2007-07-18 | 84 | 2007-07-16 | 2007-07-18 | 3d | 16d | 0d | کارگر ساده [2%]; گچ [30 کیسه]; گچکار [2%] | 0.96h | 62.66 | 62.66 |
| 90 | 1.4.1.38 | سنگ کردن راه پله ها ودیوار آن تا ارتفع یک متر | 16d | 2007-07-05 | 2007-07-20 | 57 | 2007-07-05 | 2007-07-20 | 16d | 15d | 0d | سنگ کار [4%]; سیمان [50 کیسه]; فرغون [2%]; کارگر ساده [5%]; ماسه [50 متر مکعب]; سنگ نما [300 متر مربع] | 14.08h | 2,823.2 | 2,823.2 |
| 91 | 1.4.1.39 | نرده های حفاظ نصب شده در تراس هاو راه پله ها | 9d | 2007-07-21 | 2007-07-29 | 90 | 2007-07-21 | 2007-07-29 | 9d | 15d |  | جوشکار [2%]; کارگر ساده [2%]; میلگرد [70 شاخه] | 2.88h | 144.35 | 144.35 |
| 92 | 1.4.1.40 | سفارش و دریافت واجرای کابینت مورد نیاز برای طبقه اول | 5d | 2007-05-25 | 2007-05-29 | 86 | 2007-05-25 | 2007-05-29 | 5d | 76d |  | کابینت [26 متر مکعب]; کارگر ساده [2%]; نصاب کابینت [2%] | 1.6h | 211.42 | 211.42 |
| 93 | 1.4.1.41 | سفارش ودریافت واجرای کابینت مورد نیاز برای طبقه دوم | 5d | 2007-06-13 | 2007-06-17 | 87 | 2007-06-13 | 2007-06-17 | 5d | 57d |  | کابینت [27 متر مکعب]; کارگر ساده [2%]; نصاب کابینت [2%] | 1.6h | 219.42 | 219.42 |
| 94 | 1.4.1.42 | سفارش ودریافت واجرای کابینت مورد نیاز برای طبقه سوم | 5d | 2007-07-03 | 2007-07-07 | 88 | 2007-07-03 | 2007-07-07 | 5d | 37d |  | کابینت [27 متر مکعب]; کارگر ساده [2%]; نصاب کابینت [2%] | 1.6h | 219.42 | 219.42 |
| 95 | 1.4.1.43 | سفارش ودریافت واجرای کابینت مورد نیاز برای طبقه چهارم | 5d | 2007-07-19 | 2007-07-23 | 89 | 2007-07-19 | 2007-07-23 | 5d | 17d | 0d | کابینت [26 متر مکعب]; کارگر ساده [2%]; نصاب کابینت [2%] | 1.6h | 211.42 | 211.42 |
| 96 | 1.4.1.44 | اجرای موکت کف اتاقها به تفکیک | 4d | 2007-07-24 | 2007-07-27 | 95 | 2007-07-24 | 2007-07-27 | 4d | 17d |  | موکت [2800 متر مربع]; کارگر ساده [3%]; نصاب در و پنجره [2%] | 1.6h | 8,403.11 | 8,403.11 |
| 97 | 1.4.1.45 | نصب کلید هاوپریز های مربوط به برق | 4d | 2007-07-16 | 2007-07-19 | 84 | 2007-07-16 | 2007-07-19 | 4d | 25d |  | برق کار [2%]; سیم برق [100 متر]; کلید وپریز [120 عدد] | 0.64h | 643.22 | 643.22 |
| 98 | 1.4.1.46 | لوله نصب شده گاز ساختمان | 10d | 2007-07-19 | 2007-07-28 | 89 | 2007-07-19 | 2007-07-28 | 10d | 16d |  | جوشکار [2%]; لوله کش گاز [4%]; لوله گاز [450 متر] | 4.8h | 3,616.13 | 3,616.13 |
| 99 | 1.4.1.47 | اجرای آردواز | 20d | 2007-06-24 | 2007-07-13 | 50 | 2007-06-24 | 2007-07-13 | 20d | 31d |  | تجهیزات آردواز [400 متر مربع]; نصاب آردواز [2%]; کارگر ساده [1%] | 4.8h | 1,811.27 | 1,811.27 |

| ID | WBS | Task | Duration | Start | Finish | Predecessors | Baseline start | Baseline finish | Baseline duration | Total slack | Free slack | Resources | Work | Cost | Baseline cost |
| --- | --- | --- | --- | --- | --- | --- | --- | --- | --- | --- | --- | --- | --- | --- | --- |
| 100 | 1.4.2 | **هماهنگی با ادارهها جهت دریافت انشعاب** | 7d | 2007-07-05 | 2007-07-11 |  | 2007-07-05 | 2007-07-11 | 7d | 6.5d |  |  | 0.64h | 42.66 | 42.66 |
| 101 | 1.4.2.1 | هماهنگی با اداره برق جهت دریافت انشعاب | 3d | 2007-07-05 | 2007-07-07 | 57 | 2007-07-05 | 2007-07-07 | 3d | 33d | 0d |  |  |  |  |
| 102 | 1.4.2.2 | نصب کنترهای برق در تابلو برق | 2d | 2007-07-10 | 2007-07-11 | 101 | 2007-07-10 | 2007-07-11 | 2d | 33d |  | برق کار [2%]; سیم برق [100 متر] | 0.32h | 41.62 | 41.62 |
| 103 | 1.4.2.3 | هماهنگی با اداره گاز جهت دریافت انشعاب | 3d | 2007-07-05 | 2007-07-07 | 57 | 2007-07-05 | 2007-07-07 | 3d | 36d | 0d |  |  |  |  |
| 104 | 1.4.2.4 | تصب کنتر گاز | 1d | 2007-07-08 | 2007-07-08 | 103 | 2007-07-08 | 2007-07-08 | 1d | 36d |  | لوله کش گاز [2%] | 0.16h | 0.68 | 0.68 |
| 105 | 1.4.2.5 | هماهنگی با اداره آبفا جهت دریافت انشعاب | 3d | 2007-07-05 | 2007-07-07 | 57 | 2007-07-05 | 2007-07-07 | 3d | 6.5d | 0d |  |  |  |  |
| 106 | 1.4.2.6 | نصب کنتر آب | 0.5d | 2007-07-08 | 2007-07-08 | 105 | 2007-07-08 | 2007-07-08 | 0.5d | 6.5d | 0d | لوله کش [2%]; کارگر ساده [2%] | 0.16h | 0.36 | 0.36 |
| 107 | 1.5 | **اجرای فاز چهارم پروزه** | 30d | 2007-07-08 | 2007-08-07 |  | 2007-07-08 | 2007-08-07 | 30d | 6.5d |  |  | 11.36h | 259.77 | 259.77 |
| 108 | 1.5.1 | **کارهای ساختمانی مربوط به اتمام پروزه** | 30d | 2007-07-08 | 2007-08-07 |  | 2007-07-08 | 2007-08-07 | 30d | 6.5d |  |  | 11.36h | 259.77 | 259.77 |
| 109 | 1.5.1.1 | پاکسازی محوطه انجام پروزه | 2.36d | 2007-07-08 | 2007-07-10 | 106 | 2007-07-08 | 2007-07-10 | 2.36d | 34.07d |  | بنا (معمار) [2%]; کارگر ساده [5%]; ماسه [10 متر مکعب]; سیمان [5 کیسه] | 0.8h | 122.71 | 122.71 |
| 110 | 1.5.1.2 | انجام ریزه کاری های باقی مانده | 22d | 2007-07-08 | 2007-07-30 | 106 | 2007-07-08 | 2007-07-30 | 22d | 6.5d | 0d | بنا (معمار) [2%]; سیمان [5 کیسه]; کارگر ساده [5%]; ماسه [10 متر مکعب] | 10.56h | 137.06 | 137.06 |
| 111 | 1.5.1.3 | فروش ماشین آلات وتجهیزات باقیمانده | 8d | 2007-07-30 | 2007-08-07 | 110 | 2007-07-30 | 2007-08-07 | 8d | 6.5d |  |  |  |  |  |
| 112 | 1.5.2 | **کارهای اداری مربوط به اتمام پروزه** | 8d | 2007-07-30 | 2007-08-07 |  | 2007-07-30 | 2007-08-07 | 8d | 6.5d |  |  |  |  |  |
| 113 | 1.5.2.1 | آماده کردن مدارک وپول جهت ارایه به شهرداری | 5d | 2007-07-30 | 2007-08-04 | 110 | 2007-07-30 | 2007-08-04 | 5d | 6.5d | 0d |  |  |  |  |
| 114 | 1.5.2.2 | ارایه مدارک و پول به شهرداری جهت دریافت پایان کار | 3d | 2007-08-04 | 2007-08-07 | 113 | 2007-08-04 | 2007-08-07 | 3d | 6.5d |  |  |  |  |  |
